# Schedule rev 4-7-08

Schedule from MS Project, 2008-03-24 to 2008-04-25, A marks actual dates.
slac

## Calendars

- Standard: Mon-Sun 07:00-12:00, 12:30-15:30. Exceptions (off unless hours are given): 2008-04-10 07:00-12:00, 12:30-16:30, 2008-04-19 to 2008-04-20.

## Resources

| Resource |
| --- |
| MFDV |
| CTL |
| Greg Hays |
| Akre |
| MFDM |
| HVAC |
| FDOI |
| Dave Dowell |
| Henrik Loos |
| V. Brown |
| M Browne |
| MET |
| MFD |
| AMRF |
| ME |
| Venkat Srinivasan |
| OHP |
| Patrick Smith |
| Erik Jongewaard |
| KLY |
| FDO |
| Phil Cutino |
| Security |
| MVDV |
| PEM |
| J. Welch |
| A. Hill |
| Antonio |
| Turner |
| Mike Harms |

## Schedule

| ID | WBS | Task | Type | Duration | Start | Finish | Predecessors | Complete | Remaining | Total slack | Free slack | Constraint | Resources | Work | Actual work |
| --- | --- | --- | --- | --- | --- | --- | --- | --- | --- | --- | --- | --- | --- | --- | --- |
| 1 | 1 | **LCLS INJECTOR SHUT-DOWN** |  | 31.12d? | 2008-03-24 07:00 A | 2008-04-25 15:30 |  | 14% | 26.62d? | 0d |  |  |  | 508.02h | 72h |
| 2 | 1.1 | **PRE-DOWN WORK** |  | 17d | 2008-03-24 07:00 A | 2008-04-10 07:00 |  | 68% | 5.45d | 14.93d |  |  |  | 106h | 72h |
| 3 | 1.1.1 | **CLEAN PARTS FOR GUN VENT** |  | 3d | 2008-03-29 07:00 | 2008-03-31 15:30 |  |  |  | 23.93d |  |  |  | 24h |  |
| 4 | 1.1.1.1 | Clean tee & purge flange |  | 24h | 2008-03-29 07:00 | 2008-03-31 15:30 |  |  |  | 23.12d |  |  | MFDV | 24h |  |
| 5 | 1.1.2 | **REPLACEMENT TOROID FOR IM01** |  | 3d | 2008-03-24 07:00 A | 2008-03-26 15:30 A |  | 100% |  |  |  |  |  | 50h | 50h |
| 6 | 1.1.2.1 | Electrical checkout |  | 2h | 2008-03-24 07:00 A | 2008-03-24 09:00 A |  | 100% |  |  |  |  | CTL | 2h | 2h |
| 7 | 1.1.2.2 | Leak check |  | 24h | 2008-03-24 07:00 A | 2008-03-26 15:30 A | 6 | 100% |  |  |  |  | MFDV | 24h | 24h |
| 8 | 1.1.2.3 | RGA |  | 24h | 2008-03-24 07:00 A | 2008-03-26 15:30 A | 7 | 100% |  |  |  |  | MFDV | 24h | 24h |
| 9 | 1.1.3 | **PRE-DOWN TASKS** |  | 14.5d | 2008-03-25 07:00 A | 2008-04-08 11:00 |  | 69% | 4.53d | 16.43d |  |  |  | 32h | 22h |
| 10 | 1.1.3.1 | Prep cathode camera |  | 8h | 2008-03-25 07:00 A | 2008-03-25 15:30 A |  | 100% |  |  |  |  | Greg Hays | 8h | 8h |
| 11 | 1.1.3.2 | Prep in-vacuum mirror |  | 8h | 2008-03-26 07:00 A | 2008-03-26 15:30 A | 10 | 100% |  |  |  |  | Greg Hays | 8h | 8h |
| 12 | 1.1.3.3 | Laser Fiducial on VV01 |  | 4h | 2008-04-02 07:00 A | 2008-04-02 11:00 A |  | 100% |  |  |  | start no earlier than 2008-04-02 07:00 | Greg Hays | 4h | 4h |
| 13 | 1.1.3.4 | Install air regulator at vault entrance (utility air use) |  | 2h | 2008-04-02 07:00 A | 2008-04-02 09:00 A | 12SS | 100% |  |  |  |  | FDOI | 2h | 2h |
| 14 | 1.1.3.5 | Re-phase 21-1D |  | 4h | 2008-04-08 07:00 | 2008-04-08 11:00 |  |  |  | 15.72d | 0d | start no earlier than 2008-04-08 07:00 | Akre | 4h |  |
| 15 | 1.1.3.6 | Install Damping on Square Strong Back for WS044 & 144 |  | 2h | 2008-04-08 07:00 | 2008-04-08 09:00 | 14SS |  |  | 15.97d |  |  | MFDM | 2h |  |
| 16 | 1.1.3.7 | Install Gear Reduction on WS02 |  | 1h | 2008-04-08 07:00 | 2008-04-08 08:00 | 14SS |  |  | 16.09d |  |  | CTL | 1h |  |
| 17 | 1.1.3.8 | Install HEPA filter on outside air vent (inside vault) |  | 2h | 2008-04-08 07:00 | 2008-04-08 09:00 | 14SS |  |  | 15.84d | 0d |  | HVAC | 2h |  |
| 18 | 1.1.3.9 | Label and Photograph RF & LCW commections |  | 1h | 2008-04-08 09:00 | 2008-04-08 10:00 | 17 |  |  | 15.84d |  |  | Dave Dowell | 1h |  |
| 19 | 1.1.4 | LCLS BEAM OFF - 7:00 AM | milestone | 0h | 2008-04-10 07:00 | 2008-04-10 07:00 |  |  |  | 13.06d | 0d | start no earlier than 2008-04-10 07:00 |  |  |  |
| 20 | 1.2 | **GTL WORK** |  | 9.87d | 2008-04-10 07:00 | 2008-04-21 13:28 |  |  |  | 4.25d |  |  |  | 160.3h |  |
| 21 | 1.2.1 | **Prep for Diagnostic Cross Removal** |  | 2.12d | 2008-04-10 07:00 | 2008-04-11 15:30 |  |  |  | 12.81d |  |  |  | 42.3h |  |
| 22 | 1.2.1.1 | Turn filaments off for Sta 20-5, 6, 7 & 8 |  | 4h | 2008-04-10 07:00 | 2008-04-10 11:00 | 19 |  |  | 13.62d |  | start no earlier than 2008-04-10 07:00 | AMRF | 4h |  |
| 23 | 1.2.1.2 | Verify OTR foils and YAGS are retracted |  | 0.5h | 2008-04-10 07:00 | 2008-04-10 07:30 | 19 |  |  | 14.06d |  |  | Henrik Loos | 0.5h |  |
| 24 | 1.2.1.3 | Laser Alignment Verification, remove Cathode camera |  | 2h | 2008-04-10 07:00 | 2008-04-10 09:00 | 19 |  |  | 13.06d | 0d |  | Greg Hays | 2h |  |
| 25 | 1.2.1.4 | Disconnect air from GTL devices |  | 1.5h | 2008-04-10 09:00 | 2008-04-10 10:30 | 24 |  |  | 13.06d | 0d |  | FDOI | 1.5h |  |
| 26 | 1.2.1.5 | Remove YAG01 & YAGG1 Camera and Optics Box |  | 1h | 2008-04-10 10:30 | 2008-04-10 11:30 | 25 |  |  | 13.06d | 0d |  | V. Brown | 1h |  |
| 27 | 1.2.1.6 | Secure Controls for AM01,YAG01 &YAGG1 |  | 0.25h | 2008-04-10 11:15 | 2008-04-10 11:30 | 26FF |  |  | 13.06d | 0d |  | CTL; V. Brown | 0.5h |  |
| 28 | 1.2.1.7 | Inspect & Tag Cabling for AM01,YAG01 &YAGG1 |  | 0.5h | 2008-04-10 11:30 | 2008-04-10 12:00 | 27 |  |  | 13.06d | 0d |  | CTL; V. Brown | 1h |  |
| 29 | 1.2.1.8 | Disconnect & Dress Cabling for AM01,YAG01 &YAGG1 |  | 0.5h | 2008-04-10 12:30 | 2008-04-10 13:00 | 28 |  |  | 13.06d | 0d |  | CTL; V. Brown | 1h |  |
| 30 | 1.2.1.9 | Secure Controls for FC01 & IM01 |  | 0.25h | 2008-04-10 12:45 | 2008-04-10 13:00 | 29FF |  |  | 13.06d | 0d |  | CTL; M Browne | 0.5h |  |
| 31 | 1.2.1.10 | Inspect & Tag Cabling for FC01 & IM01 |  | 0.5h | 2008-04-10 13:00 | 2008-04-10 13:30 | 30 |  |  | 13.06d | 0d |  | CTL; M Browne | 1h |  |
| 32 | 1.2.1.11 | Disconnect & Dress Cabling for FC01 & IM01 |  | 0.5h | 2008-04-10 13:30 | 2008-04-10 14:00 | 31 |  |  | 13.06d | 0d |  | CTL; M Browne | 1h |  |
| 33 | 1.2.1.12 | Lock&Tag PS for Bucking Coil, SOL1 & 2, all inj magnets |  | 1h | 2008-04-10 07:00 | 2008-04-10 08:00 | 19 |  |  | 14.28d | 0.12d |  | Patrick Smith | 1h |  |
| 34 | 1.2.1.13 | Tag and label Bucking Coil power leads |  | 0.2h | 2008-04-10 09:00 | 2008-04-10 09:12 | 33, 24 |  |  | 13.35d | 0d |  | MFDM | 0.2h |  |
| 35 | 1.2.1.14 | Remove power leads to Bucking Coil |  | 0.2h | 2008-04-10 09:12 | 2008-04-10 09:24 | 34 |  |  | 13.35d | 0d |  | MFDM | 0.2h |  |
| 36 | 1.2.1.15 | Tag and remove jumpers to RF pickups |  | 0.5h | 2008-04-10 09:24 | 2008-04-10 09:54 | 35 |  |  | 13.35d | 0d |  | Erik Jongewaard | 0.5h |  |
| 37 | 1.2.1.16 | Tag & Remove RF Pickup leads |  | 0.5h | 2008-04-10 09:54 | 2008-04-10 10:24 | 36 |  |  | 13.35d | 0d |  | KLY | 0.5h |  |
| 38 | 1.2.1.17 | Shut off LCW for Gun Cathode -LOTO |  | 0.2h | 2008-04-10 10:24 | 2008-04-10 10:36 | 37 |  |  | 13.35d | 0d |  | FDO | 0.2h |  |
| 39 | 1.2.1.18 | Drain LCW, blow lines w nitrogen or compressed air |  | 1h | 2008-04-10 10:36 | 2008-04-10 11:36 | 38 |  |  | 13.35d | 0d |  | FDO; Phil Cutino | 2h |  |
| 40 | 1.2.1.19 | Loosen LCW fittings for Gun Cathode |  | 0.2h | 2008-04-10 11:36 | 2008-04-10 11:48 | 39 |  |  | 13.35d | 0d |  | MFDM | 0.2h |  |
| 41 | 1.2.1.20 | Remove LCW lines |  | 0.2h | 2008-04-10 11:48 | 2008-04-10 12:00 | 40 |  |  | 13.35d | 0d |  | MFDM | 0.2h |  |
| 42 | 1.2.1.21 | Cap Cathode LCW lines |  | 0.2h | 2008-04-10 12:30 | 2008-04-10 12:42 | 41 |  |  | 13.35d | 0d |  | MFDM | 0.2h |  |
| 43 | 1.2.1.22 | Remove Bucking Coil |  | 1h | 2008-04-10 12:42 | 2008-04-10 13:42 | 42 |  |  | 13.35d |  |  | Erik Jongewaard | 1h |  |
| 44 | 1.2.1.23 | Close TCAV RF Valve on Injector Side |  | 1h | 2008-04-10 09:00 | 2008-04-10 10:00 | 24 |  |  | 13.72d | 0d | start no earlier than 2008-04-10 07:00 | MFDV | 1h |  |
| 45 | 1.2.1.24 | Lock VV01 valve controller to CLOSED mode |  | 0.2h | 2008-04-10 10:00 | 2008-04-10 10:12 | 44 |  |  | 13.72d | 0d |  | MFDV | 0.2h |  |
| 46 | 1.2.1.25 | Close VV04 |  | 0.2h | 2008-04-10 10:00 | 2008-04-10 10:12 | 45FF |  |  | 13.72d | 0d |  | MFDV | 0.2h |  |
| 47 | 1.2.1.26 | Verify VV02 and VV03 are Open |  | 0.2h | 2008-04-10 10:00 | 2008-04-10 10:12 | 46FF |  |  | 13.72d |  |  | MFDV | 0.2h |  |
| 48 | 1.2.1.27 | Stage Equipment and setup to vent from VV01 thru VV04 |  | 8h | 2008-04-11 07:00 | 2008-04-11 15:30 |  |  |  | 12d |  | finish no earlier than 2008-04-11 15:30 | MFDV | 8h |  |
| 49 | 1.2.1.28 | Bring equipment downstairs (no acess to vault during crane ops) |  | 2h | 2008-04-10 14:00 | 2008-04-10 16:00 | 32 |  |  | 13.06d |  |  | MFDM | 2h |  |
| 50 | 1.2.1.29 | Initial Pos.Survey GTL diagnostics, RF Gun and Table |  | 8h | 2008-04-11 07:00 | 2008-04-11 15:30 |  |  |  | 12d | 0d | start no earlier than 2008-04-11 07:00 | MET | 8h |  |
| 51 | 1.2.1.30 | Install Tooling Balls on Gun Flange |  | 0.5h | 2008-04-11 07:00 | 2008-04-11 07:30 | 50SS |  |  | 12.94d |  | start no earlier than 2008-03-29 07:00 | MET | 0.5h |  |
| 52 | 1.2.1.31 | LOTO Vault magnets, Modulators, etc |  | 2h | 2008-04-11 13:30 | 2008-04-11 15:30 | 50FF |  |  | 12d |  |  | MFD | 2h |  |

| ID | WBS | Task | Type | Duration | Start | Finish | Predecessors | Total slack | Free slack | Constraint | Resources | Work |
| --- | --- | --- | --- | --- | --- | --- | --- | --- | --- | --- | --- | --- |
| 53 | 1.2.2 | **Diagnostics Cross Removal & Repairs** |  | 6.12d | 2008-04-12 07:00 | 2008-04-18 08:00 |  | 2.85d |  |  |  | 89.5h |
| 54 | 1.2.2.1 | Laser Alignment Verification, remove Cathode camera |  | 0.5h | 2008-04-12 07:00 | 2008-04-12 07:30 |  | 3.91d | 0d | start no earlier than 2008-04-12 07:00 | Greg Hays | 0.5h |
| 55 | 1.2.2.2 | Begin logging Gun Vacuum | milestone | 0h | 2008-04-12 07:30 | 2008-04-12 07:30 | 54 | 3.91d | 0d | start no earlier than 2008-04-12 07:12 | MFDV |  |
| 56 | 1.2.2.3 | Vent VV01 to VV04 |  | 1h | 2008-04-12 07:30 | 2008-04-12 08:30 | 55 | 3.91d | 0d |  | MFDV | 1h |
| 57 | 1.2.2.4 | Remove Diagnostics Cross and take to Vacuum lab |  | 4.5h | 2008-04-12 08:30 | 2008-04-12 13:30 | 56 | 1.22d | 0d |  | MFDV | 4.5h |
| 58 | 1.2.2.5 | Remove YAGG1 and take to Vacuum Lab |  | 2h | 2008-04-12 13:30 | 2008-04-12 15:30 | 57 | 2.22d | 1.12d |  | MFDV | 2h |
| 59 | 1.2.2.6 | Install window in place of IM01 |  | 0.5h | 2008-04-13 07:00 | 2008-04-13 07:30 | 58 | 4.53d | 0.94d | start no earlier than 2008-03-29 07:00 | MFDV | 0.5h |
| 60 | 1.2.2.7 | Make Call for Friday GTL Install | milestone | 0d | 2008-04-15 15:19 | 2008-04-15 15:19 |  | 8.02d |  | start no earlier than 2008-04-15 15:19 | Phil Cutino |  |
| 61 | 1.2.2.8 | **Vacuum Lab Repair of Diagnostics Cross** |  | 5.38d | 2008-04-12 13:30 | 2008-04-18 08:00 |  | 5.88d |  |  |  | 69h |
| 62 | 1.2.2.8.1 | Setup Diagnostic Cross for Initial Survey |  | 1h | 2008-04-12 13:30 | 2008-04-12 14:30 | 57 | 3.69d | 0.12d | start no earlier than 2008-03-29 07:00 | MFDV | 1h |
| 63 | 1.2.2.8.2 | Survery Diagnostic Cross |  | 4h | 2008-04-13 07:00 | 2008-04-13 11:00 | 62 | 3.56d | 0d | start no earlier than 2008-04-13 07:00 | MET | 4h |
| 64 | 1.2.2.8.3 | Remove YAG01/FC01 Screen Assembly |  | 1h | 2008-04-13 11:00 | 2008-04-13 12:00 | 63 | 5.88d | 0d | start no earlier than 2008-03-29 07:00 | MFDV | 1h |
| 65 | 1.2.2.8.4 | Dissassemble YAG01/FC01 Screen Assembly |  | 3h | 2008-04-13 12:30 | 2008-04-13 15:30 | 64 | 5.88d | 0d | start no earlier than 2008-03-29 07:00 | MFDV | 3h |
| 66 | 1.2.2.8.5 | Repair FC01 Wiring |  | 2h | 2008-04-14 07:00 | 2008-04-14 09:00 | 65 | 5.88d | 0d |  | MFDV | 2h |
| 67 | 1.2.2.8.6 | Reassemble YAG01/FC01 Screen Assembly |  | 4h | 2008-04-14 09:00 | 2008-04-14 13:30 | 66 | 5.88d | 0d | start no earlier than 2008-03-29 07:00 | MFDV | 4h |
| 68 | 1.2.2.8.7 | Turn AM01 Mirror around |  | 2h | 2008-04-14 13:30 | 2008-04-14 15:30 | 67 | 5.88d | 0d |  | MFDV | 2h |
| 69 | 1.2.2.8.8 | Adjust YAG01 Actuator |  | 2h | 2008-04-15 07:00 | 2008-04-15 09:00 | 68 | 5.88d | 0d | start no earlier than 2008-03-29 07:00 | MFDV | 2h |
| 70 | 1.2.2.8.9 | Adjust AM01 Actuator |  | 2h | 2008-04-15 09:00 | 2008-04-15 11:00 | 69 | 5.88d | 0d | start no earlier than 2008-03-29 07:00 | MFDV | 2h |
| 71 | 1.2.2.8.10 | Replace Struts for YAG01/FC01/AM01 |  | 12h | 2008-04-15 11:00 | 2008-04-16 15:30 | 70 | 5.88d | 0d | start no earlier than 2008-03-29 07:00 | MFDV | 12h |
| 72 | 1.2.2.8.11 | Replace IM01 |  | 2h | 2008-04-17 07:00 | 2008-04-17 09:00 | 71 | 5.88d | 0d |  | MFDV | 2h |
| 73 | 1.2.2.8.12 | Setup Diagnostic Cross for Final Bench Alignment |  | 1h | 2008-04-17 09:00 | 2008-04-17 10:00 | 72 | 5.88d | 0d | start no earlier than 2008-03-29 07:00 | MFDV | 1h |
| 74 | 1.2.2.8.13 | Align YAG01/FC01/AM01 |  | 4h | 2008-04-17 10:00 | 2008-04-17 14:30 | 73 | 5.88d | 0d | start no earlier than 2008-03-29 07:00 | MET | 4h |
| 75 | 1.2.2.8.14 | Replace outcoupling In-Vacuum Mirror |  | 1h | 2008-04-17 10:00 | 2008-04-17 11:00 | 73 | 6.38d | 0d |  | Greg Hays | 1h |
| 76 | 1.2.2.8.15 | Inspect in-coupling In-vacuum mirror, and replace if necessary |  | 1h | 2008-04-17 11:00 | 2008-04-17 12:00 | 75 | 6.38d |  |  | Greg Hays | 1h |
| 77 | 1.2.2.8.16 | Pump Down & Leak Check Diagnostics Cross |  | 1h | 2008-04-17 14:30 | 2008-04-17 15:30 | 74 | 5.88d | 0d |  | MFDV | 1h |
| 78 | 1.2.2.8.17 | Return Diagnostics Cross to Sector 20 |  | 1h | 2008-04-18 07:00 | 2008-04-18 08:00 | 77 | 5.88d |  |  | MFDV | 1h |
| 79 | 1.2.2.8.18 | SetupYAGG1 for Initial Survey |  | 1h | 2008-04-13 11:00 | 2008-04-13 12:00 | 63 | 3.56d | 0d | start no earlier than 2008-03-29 07:00 | MFDV | 1h |
| 80 | 1.2.2.8.19 | Survey YAGG1 |  | 4h | 2008-04-13 12:30 | 2008-04-14 08:00 | 79 | 3.56d | 0d | start no earlier than 2008-03-29 07:00 | MET | 4h |
| 81 | 1.2.2.8.20 | Set hard stops for YAGG1 actuator |  | 3h | 2008-04-14 08:00 | 2008-04-14 11:00 | 80 | 3.56d | 0d |  | MFDV | 3h |
| 82 | 1.2.2.8.21 | Replace Struts for YAGG1 |  | 12h | 2008-04-14 11:00 | 2008-04-15 15:30 | 81 | 3.56d | 0d | start no earlier than 2008-03-29 07:00 | MFDV | 12h |
| 83 | 1.2.2.8.22 | Align YAGG1 |  | 4h | 2008-04-16 07:00 | 2008-04-16 11:00 | 82 | 3.56d | 0d | start no earlier than 2008-03-29 07:00 | MET | 4h |
| 84 | 1.2.2.8.23 | Return YAGG1 to Sector 20 |  | 1h | 2008-04-16 11:00 | 2008-04-16 12:00 | 83 | 7.38d |  | start no earlier than 2008-03-29 07:00 | MFDV | 1h |
| 85 | 1.2.2.9 | Setup Mirror and Camera to Site Downbeam to YAG02 |  | 4h | 2008-04-14 08:00 | 2008-04-14 12:00 | 58, 80 | 8.88d | 0d | start no earlier than 2008-03-29 07:00 | MET | 4h |
| 86 | 1.2.2.10 | Check alignment and wakefield plugs of YAG02 & CR01 |  | 2h | 2008-04-14 12:30 | 2008-04-14 14:30 | 85 | 8.88d | 0d |  | MET; MFDV | 4h |
| 87 | 1.2.2.11 | Check alignment of BPM3 & YAG02 |  | 2h | 2008-04-14 14:30 | 2008-04-15 08:00 | 86 | 8.88d |  |  | MFDV; MET | 4h |

| ID | WBS | Task | Duration | Start | Finish | Predecessors | Total slack | Free slack | Constraint | Resources | Work |
| --- | --- | --- | --- | --- | --- | --- | --- | --- | --- | --- | --- |
| 88 | 1.2.3 | **GTL Reinstall** | 2.94d | 2008-04-16 13:58 | 2008-04-21 13:28 |  | 0.41d |  |  |  | 28.5h |
| 89 | 1.2.3.1 | Reinstall Diagnostics Cross Loose | 4h | 2008-04-16 13:58 | 2008-04-17 09:28 | 126 | 0.41d | 0d |  | MFDV; MET | 8h |
| 90 | 1.2.3.2 | Align Diagnostics Cross | 4h | 2008-04-17 09:28 | 2008-04-17 13:58 | 89 | 0.41d | 0d |  | MET | 4h |
| 91 | 1.2.3.3 | Tighten flanges for diagnostic cross | 1.5h | 2008-04-17 13:58 | 2008-04-17 15:28 | 90 | 0.41d | 0d |  | MFDV | 1.5h |
| 92 | 1.2.3.4 | Install YAGG1 | 3h | 2008-04-17 15:28 | 2008-04-18 09:58 | 91 | 0.41d | 0d | start no earlier than 2008-03-29 07:00 |  |  |
| 93 | 1.2.3.5 | Align YAGG1 | 2h | 2008-04-18 09:58 | 2008-04-18 11:58 | 92 | 0.41d | 0d | start no earlier than 2008-03-29 07:00 |  |  |
| 94 | 1.2.3.6 | Tighten Flange for YAGG1 | 1h | 2008-04-18 11:58 | 2008-04-18 13:28 | 93 | 0.41d | 0d | start no earlier than 2008-03-29 07:00 |  |  |
| 95 | 1.2.3.7 | Inspect YAG01 & YAGG1 acutator motion | 1h | 2008-04-18 13:28 | 2008-04-18 14:28 | 94 | 0.41d | 0d |  | ME; Venkat Srinivasan | 2h |
| 96 | 1.2.3.8 | Connect & Dress Cabling for AM01,YAG01 &YAGG1 | 1h | 2008-04-18 14:28 | 2008-04-18 15:28 | 95 | 0.41d | 0d |  | CTL; V. Brown | 2h |
| 97 | 1.2.3.9 | Restore Controls for AM01,YAG01 &YAGG1 | 0.5h | 2008-04-18 15:28 | 2008-04-21 07:28 | 96 | 4.25d | 0d |  | CTL; V. Brown | 1h |
| 98 | 1.2.3.10 | Checkout Controls for AM01,YAG01 &YAGG1 | 1h | 2008-04-21 07:28 | 2008-04-21 08:28 | 97 | 4.25d | 0d |  | CTL; V. Brown | 2h |
| 99 | 1.2.3.11 | Connect & Dress Cabling for FC01 & IM01 | 1h | 2008-04-21 08:28 | 2008-04-21 09:28 | 98 | 4.25d | 0d |  | CTL; M Browne | 2h |
| 100 | 1.2.3.12 | Restore Controls for FC01 & IM01 | 0.5h | 2008-04-21 09:28 | 2008-04-21 09:58 | 99 | 4.25d | 0d |  | CTL; M Browne | 1h |
| 101 | 1.2.3.13 | Checkout Controls for FC01 & IM01 | 1h | 2008-04-21 09:58 | 2008-04-21 10:58 | 100 | 4.25d | 0d |  | CTL; M Browne | 2h |
| 102 | 1.2.3.14 | Check out MPS Shutter Wiring, opearation | 1h | 2008-04-21 10:58 | 2008-04-21 11:58 | 101 | 4.25d | 0d | start no earlier than 2008-04-07 08:00 | CTL; M Browne | 2h |
| 103 | 1.2.3.15 | Install Cathode CCD and Check laser alignment of diagnostics cross | 1h | 2008-04-21 11:58 | 2008-04-21 13:28 | 102 | 4.25d |  |  | Greg Hays | 1h |
| 104 | 1.3 | **Gun Work** | 9.59d | 2008-04-14 07:00 | 2008-04-25 11:43 |  | 0.41d |  |  |  | 39.72h |
| 105 | 1.3.1 | **PREP WORK - REPLACE RF PICKUPS** | 0.5d | 2008-04-14 07:00 | 2008-04-14 11:00 |  | 1.5d |  |  |  | 4h |
| 106 | 1.3.1.1 | Prep Nitrogen purge to gun down stairs | 1h | 2008-04-14 07:00 | 2008-04-14 08:00 | 59 | 1.5d | 0d | start no earlier than 2008-04-14 07:00 | MFDV | 1h |
| 107 | 1.3.1.2 | Install Air Shower - (no other work in area - overhead work) | 2h | 2008-04-14 08:00 | 2008-04-14 10:00 | 106 | 1.5d | 0d |  | MFDV | 2h |
| 108 | 1.3.1.3 | Wipe all Surfaces Near Gun Down | 1h | 2008-04-14 10:00 | 2008-04-14 11:00 | 107 | 1.5d |  |  | MFDV | 1h |
| 109 | 1.3.2 | **REMOVE AND REPLACE RF PROBES** | 7.59d | 2008-04-16 07:00 | 2008-04-25 11:43 |  | 0.41d |  |  |  | 35.72h |
| 110 | 1.3.2.1 | Secure area outside near air intake | 5h | 2008-04-16 07:00 | 2008-04-16 12:00 | 108 | 7.07d | 0d | start no earlier than 2008-04-16 07:00 | Security | 5h |
| 111 | 1.3.2.2 | Close bakeable valve to RGA | 0.2h | 2008-04-16 07:00 | 2008-04-16 07:12 | 110SS | 7.07d | 0d |  | MFDV | 0.2h |
| 112 | 1.3.2.3 | Turn off Gun vacuum gauges | 0.2h | 2008-04-16 07:12 | 2008-04-16 07:24 | 111 | 7.07d | 0d |  | MFDV | 0.2h |
| 113 | 1.3.2.4 | Install Venting Pumpout cross and leak detector on Gun | 0.5h | 2008-04-16 07:24 | 2008-04-16 07:54 | 112 | 7.07d | 0d |  | MFDV | 0.5h |
| 114 | 1.3.2.5 | Pump & Backfill Manifold | 1h | 2008-04-16 07:54 | 2008-04-16 08:54 | 113 | 7.07d | 0d | start no earlier than 2008-03-29 07:00 | MFDV | 1h |
| 115 | 1.3.2.6 | Turn off Gun ion pumps | 0.2h | 2008-04-16 08:54 | 2008-04-16 09:06 | 114 | 7.07d | 0d |  | MFDV | 0.2h |
| 116 | 1.3.2.7 | Start purge (PRV upstairs) | 0.2h | 2008-04-16 09:06 | 2008-04-16 09:18 | 115 | 7.07d | 0d |  | MFDV | 0.2h |
| 117 | 1.3.2.8 | Open Gun pump-out valve | 0.2h | 2008-04-16 09:18 | 2008-04-16 09:30 | 116 | 7.07d | 0d |  | MFDV | 0.2h |
| 118 | 1.3.2.9 | Vent Gun | 0.25h | 2008-04-16 09:30 | 2008-04-16 09:45 | 117 | 7.07d | 0d |  | MFDV | 0.25h |
| 119 | 1.3.2.10 | Remove and replace one RF pickup at the time (Mini CF + nut plates) X 4 | 1.5h | 2008-04-16 09:45 | 2008-04-16 11:15 | 118 | 7.07d | 0d |  | MFDV; Erik Jongewaard | 3h |
| 120 | 1.3.2.11 | Electrical check of RF pickups | 0.12h | 2008-04-16 11:15 | 2008-04-16 11:22 | 119 | 7.07d | 0d |  | MFDV; Erik Jongewaard | 0.27h |
| 121 | 1.3.2.12 | Stop purge after 4th RF pickup is installed | 0.1h | 2008-04-16 11:22 | 2008-04-16 11:28 | 120 | 7.07d | 0d |  | MFDV; Erik Jongewaard | 0.2h |
| 122 | 1.3.2.13 | Pump-down Gun | 1h | 2008-04-16 11:28 | 2008-04-16 12:58 | 121 | 7.07d | 0d |  | MFDV | 1h |
| 123 | 1.3.2.14 | Replace VP640 | 2h | 2008-04-16 11:28 | 2008-04-16 13:58 | 122SS | 8d |  | start no earlier than 2008-04-07 08:00 | MFDV | 2h |
| 124 | 1.3.2.15 | Leak check Gun | 0.5h | 2008-04-16 12:58 | 2008-04-16 13:28 | 122 | 7.07d | 0d |  | MFDV | 0.5h |
| 125 | 1.3.2.16 | Start ion pumps if N.I.L (If not N.I.L, fix leak) | 0.5h | 2008-04-16 13:28 | 2008-04-16 13:58 | 124 | 8d |  |  | MFDV | 0.5h |
| 126 | 1.3.2.17 | Start vacuum gauges | 0.5h | 2008-04-16 13:28 | 2008-04-16 13:58 | 124 | 7.07d | 0d |  | MFDV | 0.5h |
| 127 | 1.3.2.18 | Valve off/remove pump cart/leak detector | 1h | 2008-04-16 13:58 | 2008-04-16 14:58 | 126 | 7.07d |  |  | MFDV | 1h |
| 128 | 1.3.2.19 | Remove plastic curtain/portable clean room | 2h | 2008-04-24 08:28 | 2008-04-24 10:28 | 149 | 0.41d | 0d |  | MFDV | 2h |
| 129 | 1.3.2.20 | Install RF pickup jumper leads | 0.5h | 2008-04-24 10:28 | 2008-04-24 10:58 | 128 | 0.41d | 0d |  | Erik Jongewaard | 0.5h |
| 130 | 1.3.2.21 | Install RF pickup leads | 1h | 2008-04-24 10:58 | 2008-04-24 11:58 | 129 | 0.41d | 0d |  | CTL | 1h |
| 131 | 1.3.2.22 | Re-survey gun and laser table location using cathode flange tooling balls, document if it moved | 4h | 2008-04-24 11:58 | 2008-04-25 07:58 | 130 | 0.41d | 0d |  | MET | 4h |
| 132 | 1.3.2.23 | Install Bucking Coil (after final alignment) | 0.5h | 2008-04-25 07:58 | 2008-04-25 08:28 | 131 | 0.41d | 0d |  | MFDM; Erik Jongewaard | 1h |
| 133 | 1.3.2.24 | Install power leads to Bucking Coil | 0.5h | 2008-04-25 08:28 | 2008-04-25 08:58 | 132 | 0.41d | 0d |  | MFDM; Erik Jongewaard | 1h |
| 134 | 1.3.2.25 | Check Bucking Coil for shorts to ground, inspect polarity, etc | 2h | 2008-04-25 08:58 | 2008-04-25 10:58 | 133 | 0.41d | 0d |  | MFDM; Erik Jongewaard; Antonio; Turner | 8h |
| 135 | 1.3.2.26 | Install Gun Cathode LCW lines | 0.5h | 2008-04-25 10:58 | 2008-04-25 11:28 | 134 | 0.41d | 0d |  | MFDM; Erik Jongewaard | 1h |
| 136 | 1.3.2.27 | Turn Gun Cathode LCW back on, check for LCW leaks | 0.25h | 2008-04-25 11:28 | 2008-04-25 11:43 | 135 | 0.41d |  |  | Phil Cutino; FDO | 0.5h |

| ID | WBS | Task | Duration | Start | Finish | Predecessors | Total slack | Free slack | Constraint | Resources | Work |
| --- | --- | --- | --- | --- | --- | --- | --- | --- | --- | --- | --- |
| 137 | 1.4 | **Replace VV03 and Realign TCAV** | 4.44d | 2008-04-18 14:28 | 2008-04-25 09:28 |  | 0.41d |  |  |  | 38h |
| 138 | 1.4.1 | Remove BSOIC near shielding wall | 1h | 2008-04-18 14:28 | 2008-04-18 15:28 | 96SS | 0.41d | 0d | start no earlier than 2008-04-01 07:00 | OHP | 1h |
| 139 | 1.4.2 | Survey TCAV for Present Position | 2h | 2008-04-18 15:28 | 2008-04-21 08:58 | 138 | 0.41d | 0d | start no earlier than 2008-04-07 08:00 |  |  |
| 140 | 1.4.3 | Run Air Line for VV03 | 3h | 2008-04-21 08:58 | 2008-04-21 11:58 | 139 | 0.41d | 0d | start no earlier than 2008-03-29 07:00 | FDOI | 3h |
| 141 | 1.4.4 | Disconnect TCAV from Beamline and waveguide to prep for alignment | 2h | 2008-04-21 11:58 | 2008-04-21 14:28 | 140 | 0.41d | 0d |  | MFDV | 2h |
| 142 | 1.4.5 | Realign TCAV Requires Realignment counterclockwise 2.5 degrees max | 2h | 2008-04-21 14:28 | 2008-04-22 07:58 | 141 | 0.41d | 0d |  | MET | 2h |
| 143 | 1.4.6 | Re-connect up- and down-beam TCAV CF & WG connections | 3h | 2008-04-22 07:58 | 2008-04-22 10:58 | 142 | 0.41d | 0d |  | MFDV | 3h |
| 144 | 1.4.7 | Realign TCAV Steering Coil | 1h | 2008-04-22 10:58 | 2008-04-22 11:58 | 143 | 0.41d | 0d |  | MET | 1h |
| 145 | 1.4.8 | Check alignment of TCAV | 1h | 2008-04-22 11:58 | 2008-04-22 13:28 | 144 | 0.41d | 0d |  | MET | 1h |
| 146 | 1.4.9 | Replace VV03 | 3h | 2008-04-22 13:28 | 2008-04-23 07:58 | 145 | 0.41d | 0d |  | MFDV | 3h |
| 147 | 1.4.10 | Connect Controls for VV03 | 2h | 2008-04-23 07:58 | 2008-04-23 09:58 | 146 | 0.41d | 0d | start no earlier than 2008-03-29 07:00 |  |  |
| 148 | 1.4.11 | Verify OTR foils and YAGS are retracted | 0.5h | 2008-04-23 09:58 | 2008-04-23 10:28 | 147 | 0.41d | 0d |  | Venkat Srinivasan; Henrik Loos | 1h |
| 149 | 1.4.12 | Pump Down and Leak Check VV01 to VV04 | 6h | 2008-04-23 10:28 | 2008-04-24 08:28 | 148, 94 | 0.41d | 0d |  | MFDV | 6h |
| 150 | 1.4.13 | Final Survey table, GTL & gun | 6h | 2008-04-24 08:28 | 2008-04-24 14:58 | 149 | 0.69d | 0d | start no earlier than 2008-03-31 08:00 | MET | 6h |
| 151 | 1.4.14 | Valve off leak detector/pump cart | 0.5h | 2008-04-24 14:58 | 2008-04-24 15:28 | 150 | 0.69d | 0d |  | MFDV | 0.5h |
| 152 | 1.4.15 | Start ion pumps/vacuum gauges | 1h | 2008-04-24 15:28 | 2008-04-25 07:58 | 151 | 0.69d | 0d |  | MFDV | 1h |
| 153 | 1.4.16 | Remove Equipment | 2h | 2008-04-24 14:58 | 2008-04-25 08:28 | 151SS | 0.82d |  |  | MFDV | 2h |
| 154 | 1.4.17 | Replace BSOIC | 1h | 2008-04-24 08:28 | 2008-04-24 09:28 | 149 | 1.44d | 0d | start no earlier than 2008-03-29 07:00 | OHP | 1h |
| 155 | 1.4.18 | Open TCAV RF valve in Injector side | 0.5h | 2008-04-25 07:58 | 2008-04-25 08:28 | 152 | 0.69d | 0d |  | MFDV | 0.5h |
| 156 | 1.4.19 | Disconnect nitrogen purge upstairs | 1h | 2008-04-25 08:28 | 2008-04-25 09:28 | 155 | 0.69d | 0d |  | MFDV | 1h |
| 157 | 1.4.20 | Turn on Filaments for 20-5, 6, 7 & 8 | 1h | 2008-04-25 08:28 | 2008-04-25 09:28 | 156FF | 0.69d |  |  | AMRF | 1h |
| 158 | 1.4.21 | Install UPS in Injector Vault | 2h | 2008-04-24 09:28 | 2008-04-24 11:28 | 154 | 1.44d |  | start no earlier than 2008-04-07 08:00 | Mike Harms | 2h |
| 159 | 1.5 | **LINAC HOUSING WORK** | 14.12d? | 2008-04-10 07:00 | 2008-04-25 15:30 |  | 0d |  |  |  | 164h |
| 160 | 1.5.1 | Change cables on BPM LI29 401 | 2h | 2008-04-10 07:00 | 2008-04-10 09:00 |  | 9.93d | 4.12d | start no earlier than 2008-04-10 07:00 | CTL | 2h |
| 161 | 1.5.2 | Repair Rad damaged cabling for LI30 Collimators | 40h | 2008-04-14 07:00 | 2008-04-18 15:30 | 160SS | 5.81d |  | start no earlier than 2008-04-14 07:00 | CTL | 40h |
| 162 | 1.5.3 | Align XCOR7 & YCOR7 | 2h | 2008-04-10 07:00 | 2008-04-10 09:00 |  | 14.68d |  | start no earlier than 2008-04-10 07:00 | MET | 2h |
| 163 | 1.5.4 | Adjust Phasing for PH03 | 4h | 2008-04-14 07:00 | 2008-04-14 11:00 |  | 10.31d |  | start no earlier than 2008-04-14 07:00 | Akre | 4h |
| 164 | 1.5.5 | Install bumpers on BC2 | 2h | 2008-04-14 07:00 | 2008-04-14 09:00 |  | 6.56d | 0d | start no earlier than 2008-04-14 07:00 | MFDM | 2h |
| 165 | 1.5.6 | Inspect Corrector Magnets in LI20 thru LI30 | 10d | 2008-04-14 07:00 | 2008-04-25 15:30 |  | 0d |  | start no earlier than 2008-04-14 07:00 | PEM | 80h |
| 166 | 1.5.7 | Check Remnant Fields on BC1 Dipoles | 2h | 2008-04-14 07:00 | 2008-04-14 09:00 |  | 10.56d |  | start no earlier than 2008-04-14 07:00 | J. Welch | 2h |
| 167 | 1.5.8 | Dress Water Hoses Around BC2 | 4h | 2008-04-14 09:00 | 2008-04-14 13:30 | 164 | 6.56d | 0d | start no earlier than 2008-03-29 07:00 | MFDM | 4h |
| 168 | 1.5.9 | Install Modified Covers for CE21 | 2h | 2008-04-14 13:30 | 2008-04-14 15:30 | 167 | 6.56d | 0d | start no earlier than 2008-03-29 07:00 | MFDM | 2h |
| 169 | 1.5.10 | Replace OTR21 Actuator Cylinder | 3h | 2008-04-15 07:00 | 2008-04-15 10:00 | 168 | 6.56d | 0d | start no earlier than 2008-03-29 07:00 | MFDM | 3h |
| 170 | 1.5.11 | Dress Water Hoses Around BC1 | 4h | 2008-04-15 10:00 | 2008-04-15 14:30 | 169 | 6.56d | 0d | start no earlier than 2008-03-29 07:00 | MFDM | 4h |
| 171 | 1.5.12 | Clean up Bias Air Installation for OTR21 | 3h | 2008-04-15 14:30 | 2008-04-16 09:00 | 170 | 6.56d | 0d | start no earlier than 2008-03-29 07:00 | FDOI | 3h |
| 172 | 1.5.13 | Install Heliax in LI21 thru LI24 | 2d | 2008-04-16 09:00 | 2008-04-18 09:00 | 171 | 6.56d |  | start no earlier than 2008-04-15 07:00 | A. Hill | 16h |
| 173 | 1.5.14 | Checkout Bld 5 Networking | 1d? | 2008-04-14 07:00 | 2008-04-14 15:30 |  | 9.81d |  | start no earlier than 2008-04-14 07:00 |  |  |
